# Aikataulu

Schedule from MS Project, 2014-12-08 to 2015-04-28.

## Calendars

- Standard: Mon-Fri 08:00-12:00, 13:00-17:00; Sat-Sun off.

## Resources

| Resource |
| --- |
| Janne |
| Aku |
| Arto |

## Schedule

| ID | WBS | Task | Type | Duration | Start | Finish | Predecessors | Total slack | Free slack | Constraint | Resources | Work |
| --- | --- | --- | --- | --- | --- | --- | --- | --- | --- | --- | --- | --- |
| 1 | 1 | **Kokonaisuus** |  | 101.12d | 2014-12-08 08:00 | 2015-04-28 09:00 |  | -58.25d | 0d |  | Aku; Arto; Janne | 14337h |
| 2 | 1.1 | **Dokumentointi** |  | 89.12d | 2014-12-08 08:00 | 2015-04-10 09:00 | 13 |  |  |  | Aku; Arto; Janne | 5815h |
| 3 | 1.1.1 | Aikataulu |  | 6d | 2014-12-08 08:00 | 2014-12-15 17:00 |  | 83.12d |  |  | Janne | 48h |
| 4 | 1.1.2 | Kutsut, agendalistat ja pöytäkirjat | manual | 86d | 2014-12-08 08:00 | 2015-04-05 17:00 | 13 |  |  |  | Arto; Janne | 1376h |
| 5 | 1.1.3 | **Loppuraportti** |  | 30.12d | 2015-03-06 08:00 | 2015-04-17 09:00 | 17 |  |  |  | Arto; Janne; Aku | 1326h |
| 6 | 1.1.3.1 | Laatiminen |  | 25d | 2015-03-06 08:00 | 2015-04-09 17:00 | 39 | 0d |  |  | Aku; Arto; Janne | 600h |
| 7 | 1.1.3.2 | Esittely |  | 1h | 2015-04-17 08:00 | 2015-04-17 09:00 | 6 | -5d | 0d | start no earlier than 2015-04-17 08:00 | Aku; Arto; Janne | 3h |
| 8 | 1.1.4 | Loppuraportti palautettu | milestone | 0d | 2015-04-17 09:00 | 2015-04-17 09:00 | 7 | -5d | 0d |  |  |  |
| 9 | 1.1.5 | **Projektisuunnitelma** |  | 23.12d | 2014-12-15 11:00 | 2015-01-15 12:00 |  | 60.62d |  |  | Aku; Arto; Janne | 926h |
| 10 | 1.1.5.1 | Laatiminen |  | 23d | 2014-12-15 11:00 | 2015-01-15 11:00 | 26 | 65.62d | 0d |  | Aku; Janne | 368h |
| 11 | 1.1.5.2 | Esittely |  | 1h | 2015-01-15 11:00 | 2015-01-15 12:00 | 10 | 65.62d | 0d |  | Aku; Arto; Janne | 3h |
| 12 | 1.1.5.3 | Suunnitelma esitelty | milestone | 0d | 2015-01-15 12:00 | 2015-01-15 12:00 | 11 | 65.62d |  |  |  |  |
| 13 | 1.2 | **Palaverit** |  | 82.12d | 2014-12-10 08:00 | 2015-04-03 09:00 |  | -84.12d | 0d |  | Aku; Arto; Janne | 1983h |
| 14 | 1.2.1 | Aloituspalaveri |  | 1h | 2014-12-10 08:00 | 2014-12-10 09:00 |  | -2.5d | 0d | start no earlier than 2014-12-10 08:00 | Aku; Arto; Janne | 3h |
| 15 | 1.2.2 | Tehtävienjakopalaveri |  | 1h | 2015-01-14 08:00 | 2015-01-14 09:00 | 14, 26 | -27.38d | 0d | start no earlier than 2015-01-14 08:00 | Aku; Arto; Janne | 3h |
| 16 | 1.2.3 | Tilannekartoituspalaveri |  | 1h | 2015-03-06 08:00 | 2015-03-06 09:00 | 14, 15, 39 | -64.25d | 0d | start no earlier than 2015-03-06 08:00 | Aku; Arto; Janne | 3h |
| 17 | 1.2.4 | Loppupalaveri |  | 1h | 2015-04-03 08:00 | 2015-04-03 09:00 | 16 | -84.12d | 0d | start no earlier than 2015-04-03 08:00 | Aku; Arto; Janne | 3h |
| 18 | 1.3 | **Seminaarit** |  | 7.12d | 2015-04-17 08:00 | 2015-04-28 09:00 |  | 0d |  |  | Aku; Arto; Janne | 423h |
| 19 | 1.3.1 | **Seminaari 1 suomeksi** |  | 5.12d | 2015-04-17 08:00 | 2015-04-24 09:00 |  |  |  |  | Aku; Arto; Janne | 166h |
| 20 | 1.3.1.1 | Valmistelu |  | 5d | 2015-04-17 08:00 | 2015-04-23 17:00 |  | 0d |  |  | Janne | 40h |
| 21 | 1.3.1.2 | Esitys |  | 1h | 2015-04-24 08:00 | 2015-04-24 09:00 | 20 | 0d |  |  | Aku; Arto; Janne | 3h |
| 22 | 1.3.2 | **Seminaari 2 englanniksi** |  | 2.12d | 2015-04-24 08:00 | 2015-04-28 09:00 | 19 |  |  |  | Aku; Arto; Janne | 86h |
| 23 | 1.3.2.1 | Valmistelu |  | 2d | 2015-04-24 08:00 | 2015-04-27 17:00 |  | 0d |  |  | Aku; Janne | 32h |
| 24 | 1.3.2.2 | Esitys |  | 1h | 2015-04-28 08:00 | 2015-04-28 09:00 | 23 | 0d |  |  | Aku; Arto; Janne | 3h |
| 25 | 1.3.2.3 | Seminaarit pidetty | milestone | 0d | 2015-04-28 09:00 | 2015-04-28 09:00 | 24 | 0d |  |  |  |  |
| 26 | 1.4 | Vierailu RK II:ssa |  | 3h | 2014-12-15 08:00 | 2014-12-15 11:00 |  | -5.75d | 0d |  | Aku; Arto; Janne | 9h |

| ID | WBS | Task | Type | Duration | Start | Finish | Predecessors | Total slack | Free slack | Constraint | Resources | Work |
| --- | --- | --- | --- | --- | --- | --- | --- | --- | --- | --- | --- | --- |
| 27 | 1.5 | **Suunnittelu** |  | 53d | 2014-12-16 08:00 | 2015-02-26 17:00 |  | -64.25d | 0d |  | Aku; Arto; Janne | 3536h |
| 28 | 1.5.1 | **Voimansiirto** |  | 31d | 2014-12-18 08:00 | 2015-01-29 17:00 | 37 | -64.25d | 0d |  | Aku; Arto; Janne | 1408h |
| 29 | 1.5.1.1 | Valinta |  | 5d | 2014-12-18 08:00 | 2014-12-24 17:00 |  | -64.25d | 0d |  | Aku; Arto; Janne | 120h |
| 30 | 1.5.1.2 | Laskenta |  | 21d | 2014-12-25 08:00 | 2015-01-22 17:00 | 29 | -64.25d | 0d |  | Aku; Arto; Janne | 504h |
| 31 | 1.5.1.3 | Osien valinta |  | 5d | 2015-01-23 08:00 | 2015-01-29 17:00 | 30 | -64.25d | 0d |  | Janne | 40h |
| 32 | 1.5.1.4 | Voimansiirto valittu | milestone | 0d | 2014-12-24 17:00 | 2014-12-24 17:00 | 29 | 36d |  |  |  |  |
| 33 | 1.5.2 | **Laakerointi** |  | 20d | 2015-01-30 08:00 | 2015-02-26 17:00 | 28 | -64.25d | 0d |  | Aku; Arto; Janne | 808h |
| 34 | 1.5.2.1 | Laskenta |  | 5d | 2015-01-30 08:00 | 2015-02-05 17:00 | 31 | 0d |  |  | Janne; Aku | 80h |
| 35 | 1.5.2.2 | Valinta |  | 1d | 2015-02-06 08:00 | 2015-02-06 17:00 | 34 | 0d |  |  | Aku; Arto; Janne | 24h |
| 36 | 1.5.2.3 | Tuenta |  | 14d | 2015-02-09 08:00 | 2015-02-26 17:00 | 35 | 0d |  |  | Arto; Aku | 224h |
| 37 | 1.5.3 | Asemointi |  | 2d | 2014-12-16 08:00 | 2014-12-17 17:00 |  | -64.25d | 0d | start no earlier than 2014-12-16 08:00 | Aku; Arto; Janne | 48h |
| 38 | 1.6 | Asennusopas ja osat |  | 1d | 2015-02-27 08:00 | 2015-02-27 17:00 | 27 | 41.12d |  |  | Aku; Arto; Janne | 24h |
| 39 | 1.7 | Lujuuslaskelmien ja selvitysten puhtaaksi kirjoitus |  | 5d | 2015-02-27 08:00 | 2015-03-05 17:00 | 27 | 0d |  |  | Aku; Arto; Janne | 120h |
